# OTIC2020

Schedule from MS Project, 2020-08-17 to 2024-12-06, costs in $.
MBARI

## Calendars

- Standard: Mon-Fri 08:00-12:00, 13:00-17:00; Sat-Sun off.

## Resources

| Resource | Rate |
| --- | --- |
| Gene Massion |  |
| Eric Martin |  |
| Paul Coenen |  |
| Dan Smith | 250 |
| New Hire | 100 |
| Scott Jensen |  |
| Jose Rosal |  |
| ETech |  |
| Mark Greise | 140 |
| Yui Takeshita |  |

## Schedule

| ID | WBS | Task | Duration | Start | Finish | Predecessors | Total slack | Free slack | Resources | Work | Cost |
| --- | --- | --- | --- | --- | --- | --- | --- | --- | --- | --- | --- |
| 1 | 1 | **System Engineering** | 49d? | 2020-10-05 | 2020-12-10 |  | 1041d |  |  | 280h |  |
| 2 | 1.1 | Refine submerge, anchor and de-anchor algorithms | 10d? | 2020-10-05 | 2020-10-16 | 48 | 1080d |  | Gene Massion | 80h |  |
| 3 | 1.2 | Refine depth control algorithm | 25d? | 2020-11-06 | 2020-12-10 | 49 | 1041d |  | Gene Massion | 200h |  |
| 4 | 2 | **Software Development** | 385d? | 2020-08-17 | 2022-02-04 |  | 740d |  |  | 1488h | 132,000 |
| 5 | 2.1 | **Refactor code** | 185d? | 2020-08-17 | 2021-04-30 |  | 740d |  |  | 1048h | 100,000 |
| 6 | 2.1.1 | **design** | 10d | 2020-08-17 | 2020-08-28 |  | 740d | 0d |  | 200h | 20,000 |
| 7 | 2.1.1.1 | Gene | 10d | 2020-08-17 | 2020-08-28 |  | 740d | 0d | Gene Massion | 80h |  |
| 8 | 2.1.1.2 | Eric | 5d | 2020-08-17 | 2020-08-21 |  | 745d |  | Eric Martin | 40h |  |
| 9 | 2.1.1.3 | Dan | 10d | 2020-08-17 | 2020-08-28 |  | 740d |  | Dan Smith | 80h | 20,000 |
| 10 | 2.1.2 | write code, test, repeat | 150d? | 2020-08-31 | 2021-03-26 | 6 | 395d | 0d | New Hire [50%] | 600h | 60,000 |
| 11 | 2.1.3 | **Develop comprehensive unit and module test framework** | 185d? | 2020-08-17 | 2021-04-30 |  | 800d | 0d |  | 248h | 20,000 |
| 12 | 2.1.3.1 | Eric | 6d? | 2020-08-31 | 2020-09-07 | 6 | 1094d |  | Eric Martin | 48h |  |
| 13 | 2.1.3.2 | new SW Hire | 100d? | 2020-08-17 | 2021-01-01 |  | 800d | 60d | New Hire [20%] | 160h | 16,000 |
| 14 | 2.1.3.3 | Fully integrate benchtop simulator into test process | 25d? | 2021-03-29 | 2021-04-30 | 10, 13 | 740d | 0d | New Hire [20%] | 40h | 4,000 |
| 15 | 2.2 | Implement sleep mode | 10d? | 2021-05-03 | 2021-05-14 | 11 | 925d | 0d | Eric Martin | 80h |  |
| 16 | 2.3 | Validate new sensor integration process | 5d? | 2021-05-17 | 2021-05-21 | 15 | 925d |  | Eric Martin | 40h |  |
| 17 | 2.4 | Develop under ice algorithms | 1d? | 2020-08-17 | 2020-08-17 |  | 1124d |  |  |  |  |
| 18 | 2.5 | Develop new mission planner | 200d? | 2021-05-03 | 2022-02-04 | 14 | 740d |  | New Hire [20%] | 320h | 32,000 |
| 19 | 3 | **Electrical Engr** | 15d? | 2020-08-17 | 2020-09-04 |  | 1110d |  |  | 472h | 22,500 |
| 20 | 3.1 | **Integrate production IMU** | 10d? | 2020-08-17 | 2020-08-28 |  | 1115d |  |  | 160h | 6,000 |
| 21 | 3.1.1 | Gene | 10d? | 2020-08-17 | 2020-08-28 |  | 1115d |  | Gene Massion | 80h |  |
| 22 | 3.1.2 | Jose | 5d? | 2020-08-17 | 2020-08-21 |  | 1120d |  | Jose Rosal | 40h |  |
| 23 | 3.1.3 | eTech | 5d? | 2020-08-17 | 2020-08-21 |  | 1120d |  | ETech | 40h |  |
| 24 | 3.2 | **Design, build, test new SOM** | 10d? | 2020-08-17 | 2020-08-28 |  | 1115d |  |  | 112h | 4,000 |
| 25 | 3.2.1 | Gene | 10d? | 2020-08-17 | 2020-08-28 |  | 1115d |  | Gene Massion | 80h |  |
| 26 | 3.2.2 | Scott | 4d? | 2020-08-17 | 2020-08-20 |  | 1121d |  | Scott Jensen | 32h |  |

Notes:
- 2: MBARI project
- 3: MBARI project
- 5: P1
- 11: P1
- 15: P1
- 16: P3
- 17: P5
- 18: P2?
- 20: P1.5
- 24: P1.5

| ID | WBS | Task | Type | Duration | Start | Finish | Predecessors | Total slack | Free slack | Resources | Work | Cost |
| --- | --- | --- | --- | --- | --- | --- | --- | --- | --- | --- | --- | --- |
| 27 | 3.3 | **Mod, build, test motherboard as necessary** |  | 5d? | 2020-08-17 | 2020-08-21 |  | 1120d |  |  | 80h | 5,000 |
| 28 | 3.3.1 | Gene |  | 5d? | 2020-08-17 | 2020-08-21 |  | 1120d |  | Gene Massion | 40h |  |
| 29 | 3.3.2 | Scott |  | 5d? | 2020-08-17 | 2020-08-21 |  | 1120d |  | Scott Jensen | 40h |  |
| 30 | 3.4 | **Design, build, test new motor controller** |  | 15d? | 2020-08-17 | 2020-09-04 |  | 1110d |  |  | 120h | 7,500 |
| 31 | 3.4.1 | Scott |  | 15d? | 2020-08-17 | 2020-09-04 |  | 1110d |  | Scott Jensen | 120h |  |
| 32 | 4 | **Mechanical Engineering** |  | 225d? | 2020-08-17 | 2021-06-25 |  | 0d |  |  | 640h | 99,600 |
| 33 | 4.1 | Drawing check |  | 100d? | 2020-08-17 | 2021-01-01 |  | 950d | 50d | Mark Greise [20%] | 160h | 22,400 |
| 34 | 4.2 | Design new housing |  | 150d? | 2020-08-17 | 2021-03-12 |  | 900d | 0d | Mark Greise [20%] | 240h | 33,600 |
| 35 | 4.3 | Update test tank prototype drawings |  | 75d? | 2020-08-17 | 2020-11-27 |  | 0d |  | Mark Greise [20%] | 120h | 16,800 |
| 36 | 4.4 | New GPS antennas |  | 75d? | 2021-03-15 | 2021-06-25 | 33, 34, 35 | 900d |  | Mark Greise [20%] | 120h | 26,800 |
| 37 | 5 | **Test** |  | 1000d? | 2021-02-08 | 2024-12-06 |  | 0d |  |  | 1280h | 128,000 |
| 38 | 5.1 | Continuous tank testing |  | 1000d? | 2021-02-08 | 2024-12-06 | 45 | 0d |  | New Hire [10%] | 800h | 80,000 |
| 39 | 5.2 | At sea engineering tests | manual | 300d | 2021-02-08 | 2022-04-01 |  |  |  | New Hire [20%] | 480h | 48,000 |
| 40 | 6 | **Science Missions** |  | 1d? | 2020-08-17 | 2020-08-17 |  | 1124d |  |  |  |  |
| 41 | 6.1 | Science missions Year 1 |  | 1d? | 2020-08-17 | 2020-08-17 |  | 1124d |  |  |  |  |
| 42 | 6.2 | Science missions Year 2 |  | 1d? | 2020-08-17 | 2020-08-17 |  | 1124d |  |  |  |  |
| 43 | 6.3 | Science missions Year 3 |  | 1d? | 2020-08-17 | 2020-08-17 |  | 1124d |  |  |  |  |
| 44 | 7 | **Production** |  | 125d? | 2020-08-17 | 2021-02-05 |  | 75d |  |  |  | 172,000 |
| 45 | 7.1 | Update test tank prototype |  | 50d | 2020-11-30 | 2021-02-05 | 35 | 0d |  |  |  | 12,000 |
| 46 | 7.2 | Build SN004 and SN005 |  | 1d? | 2020-08-17 | 2020-08-17 |  | 1124d |  |  |  | 160,000 |
| 47 | 8 | **Technology transfer** |  | 49d? | 2020-08-31 | 2020-11-05 |  | 1041d |  |  | 176h |  |
| 48 | 8.1 | Develop and conduct potential users survey |  | 25d? | 2020-08-31 | 2020-10-02 | 7 | 1041d | 0d | Gene Massion [20%]; Yui Takeshita [33%] | 80h |  |
| 49 | 8.2 | Develop TT strategy |  | 24d? | 2020-10-05 | 2020-11-05 | 48 | 1041d | 0d | Gene Massion [25%]; Yui Takeshita [25%] | 96h |  |
| 51 | 9 | **Materials** |  | 780d | 2020-08-17 | 2023-08-11 |  | 345d |  |  |  | 22,500 |
| 52 | 9.1 | Year 1 |  | 260d | 2020-08-17 | 2021-08-13 |  | 345d | 0d |  |  | 7,500 |
| 53 | 9.2 | Year 2 |  | 260d | 2021-08-16 | 2022-08-12 | 52 | 345d | 0d |  |  | 10,000 |
| 54 | 9.3 | Year 3 |  | 260d | 2022-08-15 | 2023-08-11 | 53 | 345d |  |  |  | 5,000 |

Notes:
- 27: P1.5
- 30: P2.5
- 33: P1
- 34: P3
- 35: P1
- 36: P2
- 38: P1
- 39: P1
- 41: MBARI project
- 42: MBARI project
- 43: MBARI project
- 45: P1
- 46: P5
- 48: P3
- 49: P5
- 52: up for discussion
- 53: up for discussion
- 54: up for discussion
